# Microsoft SharePoint 2010 Project Implementation Plan

Schedule from MS Project, 2010-01-01 to 2010-04-13.
THIS IS A TEMPLATE SHOWING THE FLOW OF A TYPICAL SHAREPOINT 2010 IMPLEMENTATION. / THIS SHOULD BE MODIFIED TO SUIT THE REQUIREMENTS OF THE CLIENT AS SHOULD THE OWNERSHIP OF TASKS DEPENDANT ON THE HUMAN RESOURCES AVAILABLE. / THIS IS RELATED TO MY BOOK: / MANAGING AND IMPLEMENTING SHAREPOINT 2010 PROJECTS WHICH YOU CAN PURCHASE FROM HERE: / http://www.microsoft-press.co.uk/scripts/product.asp?ref=189322 / BEST REGARDS / GEOFF EVELYN

## Calendars

- Standard: Mon-Fri 08:00-12:00, 13:00-17:00; Sat-Sun off.

## Resources

| Resource |
| --- |
| Project Manager |
| MOSS 2007 Administrator |
| Desktop Administrator |
| Intranet/Internet Administrator |
| Workspace Coordinators |
| Database Administrator |
| Test/QA Lead |
| End Users |
| Education/Training Lead |
| SharePoint 2010 Administrator |
| SharePoint 2010 Architect |
| Interfacing Teams |
| SharePoint Administrator |
| StakeHolders |
| SharePoint Architect |

## Schedule

| ID | WBS | Task | Duration | Start | Finish | Predecessors | Total slack | Constraint | Resources | Work |
| --- | --- | --- | --- | --- | --- | --- | --- | --- | --- | --- |
| 1 | 1 | **Microsoft SharePoint 2010 Implementation Plan** | 73d | 2010-01-01 | 2010-04-13 |  | 0d |  |  | 3376h |
| 2 | 1.1 | **Envisioning** | 8d | 2010-01-01 | 2010-01-12 |  | 0d |  |  | 120h |
| 3 | 1.1.1 | Evaluate Microsoft SharePoint 2010 features | 1d | 2010-01-01 | 2010-01-01 |  | 0d |  | SharePoint 2010 Architect; StakeHolders | 16h |
| 4 | 1.1.2 | Evaluate corporate objectives for Microsoft SharePoint 2010 (corporate knowledge sharing) | 1d | 2010-01-04 | 2010-01-04 | 3 | 0d |  | StakeHolders | 8h |
| 5 | 1.1.3 | Evaluate customer needs for Microsoft SharePoint 2010 | 1d | 2010-01-05 | 2010-01-05 | 4 | 0d |  | StakeHolders | 8h |
| 6 | 1.1.4 | Formulate preliminary cost/benefit analysis | 1d | 2010-01-06 | 2010-01-06 | 5 | 0d |  | StakeHolders | 8h |
| 7 | 1.1.5 | Determine project scope (lab, pilot, international/regional deployment, coexistence strategies, etc.) | 1d | 2010-01-07 | 2010-01-07 | 6 | 0d |  | Project Manager; StakeHolders | 16h |
| 8 | 1.1.6 | Determine major milestones | 1d | 2010-01-08 | 2010-01-08 | 7 | 0d |  | Project Manager; StakeHolders | 16h |
| 9 | 1.1.7 | Secure executive sponsorship and funding | 1d | 2010-01-11 | 2010-01-11 | 8 | 0d |  | Project Manager; StakeHolders | 16h |
| 10 | 1.1.8 | Document as needed | 1d | 2010-01-12 | 2010-01-12 | 9 | 0d |  | Project Manager; StakeHolders | 16h |
| 11 | 1.1.9 | Envisioning complete | 1d | 2010-01-01 | 2010-01-01 |  | 7d | start no earlier than 2010-01-01 | Project Manager; StakeHolders | 16h |
| 12 | 1.2 | **PLAN PHASE** | 35d | 2010-01-13 | 2010-03-02 | 2 | 0d |  |  | 1608h |
| 13 | 1.2.1 | Define vision statement for requirements | 1d | 2010-01-13 | 2010-01-13 |  | 64d |  | Project Manager; StakeHolders | 16h |
| 14 | 1.2.2 | Determine success criteria | 1d | 2010-01-13 | 2010-01-13 |  | 64d |  | Project Manager; StakeHolders | 16h |
| 15 | 1.2.3 | **Assemble Project Teams, Define Roles** | 4d | 2010-01-13 | 2010-01-18 |  | 0d |  |  | 136h |
| 16 | 1.2.3.1 | Assemble Project Teams | 1d | 2010-01-13 | 2010-01-13 |  | 3d |  | Project Manager | 8h |
| 17 | 1.2.3.2 | Assign/define Development/Design team | 1d | 2010-01-13 | 2010-01-13 |  | 3d |  | Project Manager | 8h |
| 18 | 1.2.3.3 | Assign/define Communication team | 1d | 2010-01-13 | 2010-01-13 |  | 3d |  | Project Manager | 8h |
| 19 | 1.2.3.4 | Assign/define project manager | 1d | 2010-01-13 | 2010-01-13 | 11 | 0d |  | Project Manager | 8h |
| 20 | 1.2.3.5 | Assign/define infrastructure/network administrator | 1d | 2010-01-13 | 2010-01-13 | 11 | 0d |  | Project Manager | 8h |
| 21 | 1.2.3.6 | Assign/define deployment administrator | 1d | 2010-01-13 | 2010-01-13 | 11 | 0d |  | Project Manager | 8h |
| 22 | 1.2.3.7 | Assign/define desktop administrator | 1d | 2010-01-13 | 2010-01-13 | 11 | 0d |  | Project Manager | 8h |
| 23 | 1.2.3.8 | Assign/define SharePoint 2010 Architect | 1d | 2010-01-13 | 2010-01-13 | 11 | 0d |  | Project Manager | 8h |
| 24 | 1.2.3.9 | Assign/define SharePoint 2010 Administrator | 1d | 2010-01-13 | 2010-01-13 |  | 3d |  | Project Manager; StakeHolders | 16h |
| 25 | 1.2.3.10 | Assign/define workspace coordinators | 1d | 2010-01-13 | 2010-01-13 | 11 | 0d |  | Project Manager | 8h |
| 26 | 1.2.3.11 | Assign/define database administrator | 1d | 2010-01-13 | 2010-01-13 | 11 | 0d |  | Project Manager | 8h |
| 27 | 1.2.3.12 | Assign/define test/QA lead | 1d | 2010-01-13 | 2010-01-13 | 11 | 0d |  | Project Manager | 8h |
| 28 | 1.2.3.13 | Assign/define education/training lead | 1d | 2010-01-13 | 2010-01-13 | 11 | 0d |  | Project Manager | 8h |
| 29 | 1.2.3.14 | Establish subteam roles and responsibilities (infrastructure, security, hosting, etc.) | 1d | 2010-01-14 | 2010-01-14 | 19, 20, 21, 22, 23, 25, 26, 27, 28 | 0d |  | Project Manager | 8h |
| 30 | 1.2.3.15 | Document as needed | 1d | 2010-01-15 | 2010-01-15 | 29 | 0d |  | Project Manager | 8h |
| 31 | 1.2.3.16 | Assemble project teams, define roles complete | 1d | 2010-01-18 | 2010-01-18 | 30 | 0d |  | Project Manager | 8h |

Notes:
- 1: THIS IS A TEMPLATE SHOWING THE FLOW OF A TYPICAL SHAREPOINT 2010 IMPLEMENTATION. / THIS SHOULD BE MODIFIED TO SUIT THE REQUIREMENTS OF THE CLIENT AS SHOULD THE OWNERSHIP OF TASKS DEPENDANT ON THE HUMAN RESOURCES AVAILABLE. / THIS IS RELATED TO MY BOOK: / MANAGING AND IMPLEMENTING SHAREPOINT 2010 PROJECTS WHICH YOU CAN PURCHASE FROM HERE:/ http://www.microsoft-press.co.uk/scripts/product.asp?ref=189322 / BEST REGARDS / GEOFF EVELYN

| ID | WBS | Task | Type | Duration | Start | Finish | Predecessors | Total slack | Free slack | Resources | Work |
| --- | --- | --- | --- | --- | --- | --- | --- | --- | --- | --- | --- |
| 32 | 1.2.4 | **Review/Detail Technical Requirements** |  | 5d | 2010-01-13 | 2010-01-19 |  | 60d |  |  | 144h |
| 33 | 1.2.4.1 | Review/detail Microsoft SharePoint 2010 requirements |  | 1d | 2010-01-13 | 2010-01-13 |  | 60d | 0d | SharePoint 2010 Architect | 8h |
| 34 | 1.2.4.2 | Content and Audit activities |  | 1d | 2010-01-13 | 2010-01-13 |  | 64d |  | SharePoint 2010 Architect | 8h |
| 35 | 1.2.4.3 | Review/detail technology architecture |  | 1d | 2010-01-13 | 2010-01-13 |  | 60d | 0d | SharePoint 2010 Architect | 8h |
| 36 | 1.2.4.4 | Review/detail server hardware and software inventory |  | 1d | 2010-01-13 | 2010-01-13 |  | 60d | 0d | SharePoint 2010 Architect | 8h |
| 37 | 1.2.4.5 | Review/detail client hardware and software inventory |  | 1d | 2010-01-13 | 2010-01-13 |  | 60d | 0d | Desktop Administrator | 8h |
| 38 | 1.2.4.6 | Review/detail current administrative/service delivery model |  | 1d | 2010-01-13 | 2010-01-13 |  | 60d | 0d | Desktop Administrator | 8h |
| 39 | 1.2.4.7 | Document current computing environment |  | 1d | 2010-01-14 | 2010-01-14 | 33, 35, 36, 37, 38 | 60d | 0d | SharePoint 2010 Architect; Desktop Administrator; Database Administrator | 24h |
| 40 | 1.2.4.8 | Document additional requirements |  | 1d | 2010-01-15 | 2010-01-15 | 39 | 60d | 0d | SharePoint 2010 Architect; Desktop Administrator; Database Administrator | 24h |
| 41 | 1.2.4.9 | Determine need for client and server licenses |  | 1d | 2010-01-18 | 2010-01-18 | 40 | 60d | 0d | SharePoint 2010 Architect; Desktop Administrator; Database Administrator | 24h |
| 42 | 1.2.4.10 | Document as needed |  | 1d | 2010-01-19 | 2010-01-19 | 41 | 60d | 0d | SharePoint 2010 Architect; Desktop Administrator; Database Administrator | 24h |
| 43 | 1.2.4.11 | Review/detail current computing environment complete | milestone | 0d | 2010-01-19 | 2010-01-19 | 42 | 60d |  | SharePoint 2010 Architect; Desktop Administrator; Database Administrator |  |
| 44 | 1.2.5 | **Review/Detail Preliminary Enduser and Business Requirements** |  | 1d | 2010-01-19 | 2010-01-19 | 15 | 60d |  |  | 56h |
| 45 | 1.2.5.1 | Determine audiences |  | 1d | 2010-01-19 | 2010-01-19 |  | 60d |  | StakeHolders | 8h |
| 46 | 1.2.5.2 | Determine User Experience requirements |  | 1d | 2010-01-19 | 2010-01-19 |  | 60d |  | StakeHolders | 8h |
| 47 | 1.2.5.3 | Determine permission and access needs |  | 1d | 2010-01-19 | 2010-01-19 |  | 60d |  | StakeHolders | 8h |
| 48 | 1.2.5.4 | Review/detail content management requirements |  | 1d | 2010-01-19 | 2010-01-19 |  | 60d |  | StakeHolders | 8h |
| 49 | 1.2.5.5 | Determine content migration requirements |  | 1d | 2010-01-19 | 2010-01-19 |  | 60d |  | StakeHolders | 8h |
| 50 | 1.2.5.6 | Document as needed |  | 1d | 2010-01-19 | 2010-01-19 |  | 60d |  | Project Manager | 8h |
| 51 | 1.2.5.7 | Review/detail taxonomy or content type requirements |  | 1d | 2010-01-19 | 2010-01-19 |  | 60d |  | StakeHolders | 8h |
| 52 | 1.2.6 | **Determine Preliminary Design Objectives** |  | 9d | 2010-01-19 | 2010-01-29 | 15 | 0d |  |  | 128h |
| 53 | 1.2.6.1 | Map vision/scope to current computing environment |  | 1d | 2010-01-19 | 2010-01-19 |  | 0d |  | Project Manager; SharePoint 2010 Architect; StakeHolders | 24h |
| 54 | 1.2.6.2 | Determine Microsoft SharePoint 2010 strategy |  | 1d | 2010-01-20 | 2010-01-20 | 53 | 0d |  | Project Manager; SharePoint 2010 Architect; StakeHolders | 24h |
| 55 | 1.2.6.3 | Determine Microsoft SharePoint 2010 storage requirements |  | 1d | 2010-01-21 | 2010-01-21 | 54 | 0d |  | SharePoint 2010 Architect; Database Administrator | 16h |
| 56 | 1.2.6.4 | Determine project information dissemination strategy (Internet, intranet, e-mail) |  | 1d | 2010-01-22 | 2010-01-22 | 55 | 0d |  | Education/Training Lead | 8h |
| 57 | 1.2.6.5 | Determine Information Architecture approach |  | 1d | 2010-01-25 | 2010-01-25 | 56 | 0d |  | StakeHolders | 8h |
| 58 | 1.2.6.6 | Determine branding requirements |  | 1d | 2010-01-26 | 2010-01-26 | 57 | 0d |  | StakeHolders | 8h |
| 59 | 1.2.6.7 | Review preliminary design objectives with executive sponsor |  | 1d | 2010-01-27 | 2010-01-27 | 58 | 0d |  | Project Manager | 8h |
| 60 | 1.2.6.8 | Document as needed |  | 1d | 2010-01-28 | 2010-01-28 | 59 | 0d |  | Project Manager | 8h |
| 61 | 1.2.6.9 | Determine preliminary design objectives complete |  | 1d | 2010-01-29 | 2010-01-29 | 60 | 0d |  | Project Manager; StakeHolders; SharePoint Architect | 24h |

| ID | WBS | Task | Duration | Start | Finish | Predecessors | Total slack | Free slack | Resources | Work |
| --- | --- | --- | --- | --- | --- | --- | --- | --- | --- | --- |
| 62 | 1.2.7 | **Identify Coexistence Strategies** | 3d | 2010-02-01 | 2010-02-03 | 52 | 0d |  |  | 48h |
| 63 | 1.2.7.1 | Identify interoperability issues within the company (operating systems supported, topology, protocol, etc.) | 1d | 2010-02-01 | 2010-02-01 |  | 1d |  | SharePoint 2010 Architect | 8h |
| 64 | 1.2.7.2 | Identify interoperability issues with the organisation's partners (topology, protocol, etc.) | 1d | 2010-02-01 | 2010-02-01 | 59 | 0d |  | SharePoint 2010 Architect | 8h |
| 65 | 1.2.7.3 | Document as needed | 1d | 2010-02-02 | 2010-02-02 | 64 | 0d |  | Project Manager; SharePoint Architect | 16h |
| 66 | 1.2.7.4 | Identify coexistence strategies complete | 1d | 2010-02-03 | 2010-02-03 | 63, 65 | 0d |  | Project Manager; SharePoint Architect | 16h |
| 67 | 1.2.8 | **Establish Test Lab Environment** | 8d | 2010-02-01 | 2010-02-10 | 52 | 12d |  |  | 64h |
| 68 | 1.2.8.1 | Select one or more lab locations | 1d | 2010-02-01 | 2010-02-01 |  | 12d | 0d | Project Manager | 8h |
| 69 | 1.2.8.2 | Determine lab space and environmental requirements | 1d | 2010-02-02 | 2010-02-02 | 68 | 12d | 0d | Project Manager | 8h |
| 70 | 1.2.8.3 | Determine power and network connection requirements | 1d | 2010-02-03 | 2010-02-03 | 69 | 12d | 0d | SharePoint 2010 Architect | 8h |
| 71 | 1.2.8.4 | Design and document logical and physical configuration for the lab | 1d | 2010-02-04 | 2010-02-04 | 70 | 12d | 0d | SharePoint 2010 Architect | 8h |
| 72 | 1.2.8.5 | Determine who needs to use the lab | 1d | 2010-02-05 | 2010-02-05 | 71 | 12d | 0d | SharePoint 2010 Architect | 8h |
| 73 | 1.2.8.6 | Define a change control process for the lab | 1d | 2010-02-08 | 2010-02-08 | 72 | 12d | 0d | SharePoint 2010 Architect | 8h |
| 74 | 1.2.8.7 | Document as needed | 1d | 2010-02-09 | 2010-02-09 | 73 | 12d | 0d | Project Manager | 8h |
| 75 | 1.2.8.8 | Establish test lab environment complete | 1d | 2010-02-10 | 2010-02-10 | 74 | 12d |  | Project Manager | 8h |
| 76 | 1.2.9 | **Perform Risk Assessment** | 5d | 2010-02-04 | 2010-02-10 | 62 | 12d |  |  | 40h |
| 77 | 1.2.9.1 | Identify and analyze potential risks | 1d | 2010-02-04 | 2010-02-04 |  | 12d | 0d | Project Manager | 8h |
| 78 | 1.2.9.2 | Quantify potential impact of the risks | 1d | 2010-02-05 | 2010-02-05 | 77 | 12d | 0d | Project Manager | 8h |
| 79 | 1.2.9.3 | Detail escalation processes | 1d | 2010-02-08 | 2010-02-08 | 78 | 12d | 0d | Project Manager | 8h |
| 80 | 1.2.9.4 | Document risk assessment | 1d | 2010-02-09 | 2010-02-09 | 79 | 12d | 0d | Project Manager | 8h |
| 81 | 1.2.9.5 | Perform risk assessment complete | 1d | 2010-02-10 | 2010-02-10 | 80 | 12d |  | Project Manager | 8h |
| 82 | 1.2.10 | **Define Communication Strategy** | 7d | 2010-02-04 | 2010-02-12 | 62 | 42d |  |  | 56h |
| 83 | 1.2.10.1 | Define communication strategy for each phase | 1d | 2010-02-04 | 2010-02-04 |  | 42d | 0d | Project Manager | 8h |
| 84 | 1.2.10.2 | Coordinate communication strategy with business owner | 1d | 2010-02-05 | 2010-02-05 | 83 | 42d | 0d | Project Manager | 8h |
| 85 | 1.2.10.3 | Define communication audiences | 1d | 2010-02-08 | 2010-02-08 | 84 | 42d | 0d | Project Manager | 8h |
| 86 | 1.2.10.4 | Define communication delivery mechanism | 1d | 2010-02-09 | 2010-02-09 | 85 | 42d | 0d | Project Manager | 8h |
| 87 | 1.2.10.5 | Establish communication timeline | 1d | 2010-02-10 | 2010-02-10 | 86 | 42d | 0d | Project Manager | 8h |
| 88 | 1.2.10.6 | Document communication strategy/standards | 1d | 2010-02-11 | 2010-02-11 | 87 | 42d | 0d | Project Manager | 8h |
| 89 | 1.2.10.7 | Define communication strategy complete | 1d | 2010-02-12 | 2010-02-12 | 88 | 42d |  | Project Manager | 8h |

| ID | WBS | Task | Duration | Start | Finish | Predecessors | Total slack | Free slack | Resources | Work |
| --- | --- | --- | --- | --- | --- | --- | --- | --- | --- | --- |
| 90 | 1.2.11 | **Define Education/Training Strategy** | 5d | 2010-02-04 | 2010-02-10 | 62 | 12d |  |  | 56h |
| 91 | 1.2.11.1 | Coordinate training strategy with business owner | 1d | 2010-02-04 | 2010-02-04 |  | 16d |  | Education/Training Lead | 8h |
| 92 | 1.2.11.2 | Define user assistance and help requirements | 1d | 2010-02-04 | 2010-02-04 |  | 16d |  | Education/Training Lead | 8h |
| 93 | 1.2.11.3 | Define education strategy for deployment demographics (administrators, help desk, end-users) | 1d | 2010-02-04 | 2010-02-04 |  | 12d | 0d | Education/Training Lead | 8h |
| 94 | 1.2.11.4 | Define education delivery mechanism | 1d | 2010-02-05 | 2010-02-05 | 93 | 12d | 0d | Education/Training Lead | 8h |
| 95 | 1.2.11.5 | Establish education timeline by phase | 1d | 2010-02-08 | 2010-02-08 | 94 | 12d | 0d | Education/Training Lead | 8h |
| 96 | 1.2.11.6 | Document education strategy/standards | 1d | 2010-02-09 | 2010-02-09 | 95 | 12d | 0d | Education/Training Lead | 8h |
| 97 | 1.2.11.7 | Define education/training strategy complete | 1d | 2010-02-10 | 2010-02-10 | 96 | 12d |  | Education/Training Lead | 8h |
| 98 | 1.2.12 | **Review Client Software and Hardware** | 7d | 2010-02-04 | 2010-02-12 | 62 | 10d |  |  | 48h |
| 99 | 1.2.12.1 | Determine existing hardware and compare to client hardware requirements | 1d | 2010-02-04 | 2010-02-04 |  | 10d | 0d | Desktop Administrator | 8h |
| 100 | 1.2.12.2 | Determine existing operating systems and software and compare to software requirements | 1d | 2010-02-05 | 2010-02-05 | 99 | 10d | 0d | Desktop Administrator | 8h |
| 101 | 1.2.12.3 | Determine if upgrade to MS Office System 2010 is beneficial | 1d | 2010-02-08 | 2010-02-08 | 100 | 10d | 0d | Desktop Administrator | 8h |
| 102 | 1.2.12.4 | Review browser requirements | 1d | 2010-02-09 | 2010-02-09 | 101 | 10d | 0d | Desktop Administrator | 8h |
| 103 | 1.2.12.5 | Upgrade client hardware and software as needed | 1d | 2010-02-10 | 2010-02-10 | 102 | 10d | 0d | Desktop Administrator | 8h |
| 104 | 1.2.12.6 | Document as needed | 1d | 2010-02-11 | 2010-02-11 | 103 | 10d | 0d | Desktop Administrator | 8h |
| 105 | 1.2.12.7 | Plan client deployment complete | 1d | 2010-02-12 | 2010-02-12 | 104 | 10d |  |  |  |
| 106 | 1.2.13 | **Create Governance Plan with Mission, Vision and Strategy** | 1d | 2010-01-13 | 2010-01-13 |  | 64d |  |  |  |
| 107 | 1.2.13.1 | Plan information portal and site collection taxonomies and heirarchies | 1d | 2010-01-13 | 2010-01-13 |  | 64d |  |  |  |
| 108 | 1.2.13.2 | Plan information policy and file plan as applicable | 1d | 2010-01-13 | 2010-01-13 |  | 64d |  |  |  |
| 109 | 1.2.13.3 | Plan branding approach | 1d | 2010-01-13 | 2010-01-13 |  | 64d |  |  |  |
| 110 | 1.2.13.4 | Plan structure | 1d | 2010-01-13 | 2010-01-13 |  | 64d |  |  |  |
| 111 | 1.2.13.5 | Plan information security policies | 1d | 2010-01-13 | 2010-01-13 |  | 64d |  |  |  |
| 112 | 1.2.14 | **Plan Server Configuration** | 11d | 2010-02-04 | 2010-02-18 | 62 | 0d |  |  | 192h |
| 113 | 1.2.14.1 | Identify document management approach | 1d | 2010-02-04 | 2010-02-04 |  | 16d |  | SharePoint 2010 Architect | 8h |
| 114 | 1.2.14.2 | Identify existing content sources (content audit or inventory) | 1d | 2010-02-04 | 2010-02-04 |  | 16d |  | SharePoint 2010 Architect | 8h |
| 115 | 1.2.14.3 | Determine content migration methodology | 1d | 2010-02-04 | 2010-02-04 |  | 16d |  | SharePoint 2010 Architect | 8h |
| 116 | 1.2.14.4 | Review server software requirements | 1d | 2010-02-04 | 2010-02-04 |  | 16d |  | SharePoint 2010 Architect | 8h |
| 117 | 1.2.14.5 | Determine redirect hosting requirements | 1d | 2010-02-04 | 2010-02-04 |  | 16d |  | SharePoint 2010 Architect | 8h |
| 118 | 1.2.14.6 | Determine Authentication provision | 1d | 2010-02-04 | 2010-02-04 |  | 16d |  | SharePoint 2010 Architect | 8h |
| 119 | 1.2.14.7 | Plan for Anonymous users | 1d | 2010-02-04 | 2010-02-04 |  | 16d |  | SharePoint 2010 Architect | 8h |
| 120 | 1.2.14.8 | Plan Recycle Bin use and Site recovery | 1d | 2010-02-04 | 2010-02-04 |  | 16d |  | SharePoint 2010 Architect | 8h |
| 121 | 1.2.14.9 | Determine site provisioning model and user experience | 1d | 2010-02-04 | 2010-02-04 |  | 16d |  | StakeHolders | 8h |

| ID | WBS | Task | Duration | Start | Finish | Predecessors | Total slack | Free slack | Resources | Work |
| --- | --- | --- | --- | --- | --- | --- | --- | --- | --- | --- |
| 122 | 1.2.14.10 | **Determine Roles and Usage Patterns of Users** | 1d | 2010-02-04 | 2010-02-04 |  | 0d |  |  | 24h |
| 123 | 1.2.14.10.1 | Identify number and anticipated usage patterns of users of the Web front end | 1d | 2010-02-04 | 2010-02-04 |  | 0d |  | Project Manager | 8h |
| 124 | 1.2.14.10.2 | Identify number and anticipated usage patterns of document management users | 1d | 2010-02-04 | 2010-02-04 |  | 0d |  | Project Manager | 8h |
| 125 | 1.2.14.10.3 | Identify number and anticipated usage patterns of search users | 1d | 2010-02-04 | 2010-02-04 |  | 0d |  | Project Manager | 8h |
| 126 | 1.2.14.11 | **Plan Capacity** | 9d | 2010-02-05 | 2010-02-17 | 122 | 0d |  |  | 88h |
| 127 | 1.2.14.11.1 | Determine normal load from roles and usage patterns | 1d | 2010-02-05 | 2010-02-05 |  | 0d |  | SharePoint 2010 Architect | 8h |
| 128 | 1.2.14.11.2 | Determine number of documents stored and document store size | 1d | 2010-02-08 | 2010-02-08 | 127 | 0d |  | SharePoint 2010 Architect | 8h |
| 129 | 1.2.14.11.3 | Estimate index size | 1d | 2010-02-09 | 2010-02-09 | 128 | 0d |  | SharePoint 2010 Architect | 8h |
| 130 | 1.2.14.11.4 | Determine needs for growth | 1d | 2010-02-10 | 2010-02-10 | 129 | 0d |  | SharePoint 2010 Architect; Database Administrator | 16h |
| 131 | 1.2.14.11.5 | Determine peak load factor | 1d | 2010-02-11 | 2010-02-11 | 130 | 0d |  | SharePoint 2010 Architect | 8h |
| 132 | 1.2.14.11.6 | Determine approach between single server, server farm, server farm with scaled service applications | 1d | 2010-02-12 | 2010-02-12 | 131 | 0d |  | SharePoint 2010 Architect | 8h |
| 133 | 1.2.14.11.7 | Evaluate caching, load balancing, and other scaling techniques | 1d | 2010-02-15 | 2010-02-15 | 132 | 0d |  | SharePoint 2010 Architect; Interfacing Teams | 16h |
| 134 | 1.2.14.11.8 | Determine future scale-out approach | 1d | 2010-02-16 | 2010-02-16 | 133 | 0d |  | SharePoint 2010 Architect | 8h |
| 135 | 1.2.14.11.9 | Draw system architecture | 1d | 2010-02-17 | 2010-02-17 | 134 | 0d |  | SharePoint 2010 Architect | 8h |
| 136 | 1.2.14.12 | Document as needed | 1d | 2010-02-04 | 2010-02-04 |  | 16d |  | SharePoint 2010 Architect | 8h |
| 137 | 1.2.14.13 | Plan server configuration complete | 1d | 2010-02-18 | 2010-02-18 | 135 | 6d |  |  |  |
| 138 | 1.2.15 | **Plan Security** | 2d | 2010-02-04 | 2010-02-05 | 62 | 15d |  |  | 152h |
| 139 | 1.2.15.1 | **Determine Microsoft SharePoint 2010 Roles** | 1d | 2010-02-04 | 2010-02-04 |  | 15d | 0d |  | 8h |
| 140 | 1.2.15.1.1 | Assign user role to provide permission to user to perform specific tasks | 1d | 2010-02-04 | 2010-02-04 |  | 15d |  | SharePoint 2010 Architect | 8h |
| 141 | 1.2.15.2 | **Define Content Security Strategy** | 1d | 2010-02-04 | 2010-02-04 |  | 15d | 0d |  | 8h |
| 142 | 1.2.15.2.1 | Utilize role-based security to control user access to content | 1d | 2010-02-04 | 2010-02-04 |  | 15d |  | SharePoint 2010 Architect | 8h |
| 143 | 1.2.15.3 | **Security Review and Lockdown** | 1d | 2010-02-04 | 2010-02-04 |  | 16d |  |  | 88h |
| 144 | 1.2.15.3.1 | Detailed review of Use Cases from threat model | 1d | 2010-02-04 | 2010-02-04 |  | 16d |  | SharePoint 2010 Architect | 8h |
| 145 | 1.2.15.3.2 | Determine Authentication provider - AD versus LDAP | 1d | 2010-02-04 | 2010-02-04 |  | 16d |  | SharePoint 2010 Architect | 8h |
| 146 | 1.2.15.3.3 | Server and Application Hardening | 1d | 2010-02-04 | 2010-02-04 |  | 16d |  | SharePoint 2010 Architect | 8h |
| 147 | 1.2.15.3.4 | Review Security Requirements | 1d | 2010-02-04 | 2010-02-04 |  | 16d |  | SharePoint 2010 Architect | 8h |
| 148 | 1.2.15.3.5 | Review AD groups | 1d | 2010-02-04 | 2010-02-04 |  | 16d |  | SharePoint 2010 Architect | 8h |
| 149 | 1.2.15.3.6 | Review security design | 1d | 2010-02-04 | 2010-02-04 |  | 16d |  | SharePoint 2010 Architect | 8h |
| 150 | 1.2.15.3.7 | Review Use Cases and Identify Data Classification | 1d | 2010-02-04 | 2010-02-04 |  | 16d |  | SharePoint 2010 Architect | 8h |
| 151 | 1.2.15.3.8 | Review & Update CRUD diagrams | 1d | 2010-02-04 | 2010-02-04 |  | 16d |  | SharePoint 2010 Architect | 8h |
| 152 | 1.2.15.3.9 | Review Infrastructure components | 1d | 2010-02-04 | 2010-02-04 |  | 16d |  | SharePoint 2010 Architect | 8h |
| 153 | 1.2.15.3.10 | Identify and document threats | 1d | 2010-02-04 | 2010-02-04 |  | 16d |  | SharePoint 2010 Architect | 8h |
| 154 | 1.2.15.3.11 | Document Security Model | 1d | 2010-02-04 | 2010-02-04 |  | 16d |  | SharePoint 2010 Architect | 8h |

| ID | WBS | Task | Duration | Start | Finish | Predecessors | Total slack | Free slack | Resources | Work |
| --- | --- | --- | --- | --- | --- | --- | --- | --- | --- | --- |
| 155 | 1.2.15.4 | **Identify Security Measures for Connecting to the Internet** | 1d | 2010-02-04 | 2010-02-04 |  | 15d | 0d |  | 40h |
| 156 | 1.2.15.4.1 | Evaluate using SSL | 1d | 2010-02-04 | 2010-02-04 |  | 15d |  | SharePoint 2010 Architect | 8h |
| 157 | 1.2.15.4.2 | Evaluate techniques to prevent unauthorized access | 1d | 2010-02-04 | 2010-02-04 |  | 15d |  | SharePoint 2010 Architect | 8h |
| 158 | 1.2.15.4.3 | Determine web application policies | 1d | 2010-02-04 | 2010-02-04 |  | 15d |  | SharePoint 2010 Architect | 8h |
| 159 | 1.2.15.4.4 | Review compliance requirements | 1d | 2010-02-04 | 2010-02-04 |  | 15d |  | SharePoint 2010 Architect | 8h |
| 160 | 1.2.15.4.5 | Determine Information Policies | 1d | 2010-02-04 | 2010-02-04 |  | 15d |  | SharePoint 2010 Architect | 8h |
| 161 | 1.2.15.5 | Document as needed | 1d | 2010-02-04 | 2010-02-04 |  | 16d |  | SharePoint 2010 Architect | 8h |
| 162 | 1.2.15.6 | Security planning complete | 1d | 2010-02-05 | 2010-02-05 | 139, 141, 155 | 15d |  |  |  |
| 163 | 1.2.16 | **Plan for Performance** | 7d | 2010-02-18 | 2010-02-26 | 62, 126 | 0d |  |  | 80h |
| 164 | 1.2.16.1 | **Performance testing of major components of SharePoint 2010** | 1d | 2010-02-18 | 2010-02-18 |  | 6d |  |  | 24h |
| 165 | 1.2.16.1.1 | My Sites | 1d | 2010-02-18 | 2010-02-18 |  | 6d |  | SharePoint 2010 Architect | 8h |
| 166 | 1.2.16.1.2 | Determine requests per second | 1d | 2010-02-18 | 2010-02-18 |  | 6d |  | SharePoint 2010 Architect | 8h |
| 167 | 1.2.16.1.3 | Measure caching performance and optimizations | 1d | 2010-02-18 | 2010-02-18 |  | 6d |  | SharePoint 2010 Architect | 8h |
| 168 | 1.2.16.2 | Review connectivity and bandwidth requirements | 1d | 2010-02-18 | 2010-02-18 |  | 0d |  | SharePoint 2010 Architect | 8h |
| 169 | 1.2.16.3 | Review current network | 1d | 2010-02-19 | 2010-02-19 | 168 | 0d |  | SharePoint 2010 Architect | 8h |
| 170 | 1.2.16.4 | Establishing minimum performance levels | 1d | 2010-02-22 | 2010-02-22 | 169 | 0d |  | SharePoint 2010 Architect | 8h |
| 171 | 1.2.16.5 | Performance testing of network | 1d | 2010-02-23 | 2010-02-23 | 170 | 0d |  | SharePoint 2010 Architect | 8h |
| 172 | 1.2.16.6 | Review network performance | 1d | 2010-02-24 | 2010-02-24 | 171 | 0d |  | SharePoint 2010 Architect | 8h |
| 173 | 1.2.16.7 | Diagram future network topology | 1d | 2010-02-25 | 2010-02-25 | 172 | 0d |  | SharePoint 2010 Architect | 8h |
| 174 | 1.2.16.8 | Upgrade WAN and LAN as required | 1d | 2010-02-26 | 2010-02-26 | 173 | 0d |  | SharePoint 2010 Architect | 8h |
| 175 | 1.2.17 | Document as needed | 1d | 2010-01-13 | 2010-01-13 |  | 64d |  | SharePoint 2010 Architect | 8h |
| 176 | 1.2.18 | Plan for network upgrades and WAN considerations | 1d | 2010-03-01 | 2010-03-01 | 174 | 31d |  |  |  |
| 177 | 1.2.19 | **Plan failover and disaster recovery** | 1d | 2010-01-13 | 2010-01-13 |  | 64d |  |  | 40h |
| 178 | 1.2.19.1 | Establish failover and disaster recovery requirements | 1d | 2010-01-13 | 2010-01-13 |  | 64d |  | SharePoint 2010 Architect | 8h |
| 179 | 1.2.19.2 | Create Failover and disaster recover plan | 1d | 2010-01-13 | 2010-01-13 |  | 64d |  | SharePoint 2010 Architect | 8h |
| 180 | 1.2.19.3 | Determine need for Microsoft Data Protection Manager (DPM) | 1d | 2010-01-13 | 2010-01-13 |  | 64d |  | SharePoint 2010 Architect | 8h |
| 181 | 1.2.19.4 | Plan Recycle Bin use and Site recovery plans | 1d | 2010-01-13 | 2010-01-13 |  | 64d |  | SharePoint 2010 Architect | 8h |
| 182 | 1.2.19.5 | Document as needed | 1d | 2010-01-13 | 2010-01-13 |  | 64d |  | SharePoint 2010 Architect | 8h |

| ID | WBS | Task | Duration | Start | Finish | Predecessors | Total slack | Free slack | Resources | Work |
| --- | --- | --- | --- | --- | --- | --- | --- | --- | --- | --- |
| 183 | 1.2.20 | **Plan for Localization** | 5d | 2010-02-04 | 2010-02-10 | 62 | 12d |  |  | 48h |
| 184 | 1.2.20.1 | Determine language used for server farm | 1d | 2010-02-04 | 2010-02-04 |  | 12d | 0d | SharePoint 2010 Architect | 8h |
| 185 | 1.2.20.2 | Determine need for Variations | 1d | 2010-02-05 | 2010-02-05 | 184 | 12d | 0d | SharePoint 2010 Architect | 8h |
| 186 | 1.2.20.3 | Install needed language packs | 1d | 2010-02-08 | 2010-02-08 | 185 | 12d | 0d | SharePoint 2010 Architect | 8h |
| 187 | 1.2.20.4 | Review search settings for locale | 1d | 2010-02-09 | 2010-02-09 | 186 | 12d | 0d | SharePoint 2010 Architect | 8h |
| 188 | 1.2.20.5 | Review language consideration | 1d | 2010-02-04 | 2010-02-04 |  | 15d | 3d | SharePoint 2010 Architect | 8h |
| 189 | 1.2.20.6 | Document as needed | 1d | 2010-02-10 | 2010-02-10 | 187, 188 | 12d |  | SharePoint 2010 Architect | 8h |
| 190 | 1.2.20.7 | Plan for localization complete | 1d | 2010-02-04 | 2010-02-04 |  | 16d |  |  |  |
| 191 | 1.2.21 | **Plan Integration** | 5d | 2010-02-04 | 2010-02-10 | 62 | 12d |  |  | 160h |
| 192 | 1.2.21.1 | **Access Services** | 1d | 2010-02-04 | 2010-02-04 |  | 16d |  | SharePoint 2010 Architect | 8h |
| 193 | 1.2.21.1.1 | Plan integration Tasks | 1d | 2010-02-04 | 2010-02-04 |  | 16d |  |  |  |
| 194 | 1.2.21.2 | **Application Registry** | 1d | 2010-02-04 | 2010-02-04 |  | 16d |  | SharePoint 2010 Architect | 8h |
| 195 | 1.2.21.2.1 | Plan integration Tasks | 1d | 2010-02-04 | 2010-02-04 |  | 16d |  |  |  |
| 196 | 1.2.21.3 | **Business Data Connectivity** | 1d | 2010-02-04 | 2010-02-04 |  | 16d |  | SharePoint 2010 Architect | 8h |
| 197 | 1.2.21.3.1 | Plan integration Tasks | 1d | 2010-02-04 | 2010-02-04 |  | 16d |  |  |  |
| 198 | 1.2.21.4 | **Excel** | 1d | 2010-02-04 | 2010-02-04 |  | 16d |  | SharePoint 2010 Architect | 8h |
| 199 | 1.2.21.4.1 | Plan integration Tasks | 1d | 2010-02-04 | 2010-02-04 |  | 16d |  |  |  |
| 200 | 1.2.21.5 | **Lotus Notes Connector** | 1d | 2010-02-04 | 2010-02-04 |  | 16d |  | SharePoint 2010 Architect | 8h |
| 201 | 1.2.21.5.1 | Plan integration Tasks | 1d | 2010-02-04 | 2010-02-04 |  | 16d |  |  |  |
| 202 | 1.2.21.6 | **Managed Metadata** | 1d | 2010-02-04 | 2010-02-04 |  | 16d |  | SharePoint 2010 Architect | 8h |
| 203 | 1.2.21.6.1 | Plan integration Tasks | 1d | 2010-02-04 | 2010-02-04 |  | 16d |  |  |  |
| 204 | 1.2.21.7 | **PerformancePoint** | 1d | 2010-02-04 | 2010-02-04 |  | 16d |  | SharePoint 2010 Architect | 8h |
| 205 | 1.2.21.7.1 | Plan integration Tasks | 1d | 2010-02-04 | 2010-02-04 |  | 16d |  |  |  |
| 206 | 1.2.21.8 | **Search** | 1d | 2010-02-04 | 2010-02-04 |  | 16d |  | SharePoint 2010 Architect | 8h |
| 207 | 1.2.21.8.1 | Plan integration Tasks | 1d | 2010-02-04 | 2010-02-04 |  | 16d |  |  |  |

| ID | WBS | Task | Duration | Start | Finish | Predecessors | Total slack | Free slack | Resources | Work |
| --- | --- | --- | --- | --- | --- | --- | --- | --- | --- | --- |
| 208 | 1.2.21.9 | **Secure Store** | 1d | 2010-02-04 | 2010-02-04 |  | 16d |  | SharePoint 2010 Architect | 8h |
| 209 | 1.2.21.9.1 | Plan integration Tasks | 1d | 2010-02-04 | 2010-02-04 |  | 16d |  |  |  |
| 210 | 1.2.21.10 | **State** | 1d | 2010-02-04 | 2010-02-04 |  | 16d |  | SharePoint 2010 Architect | 8h |
| 211 | 1.2.21.10.1 | Plan integration Tasks | 1d | 2010-02-04 | 2010-02-04 |  | 16d |  |  |  |
| 212 | 1.2.21.11 | **Usage and Health** | 1d | 2010-02-04 | 2010-02-04 |  | 16d |  | SharePoint 2010 Architect | 8h |
| 213 | 1.2.21.11.1 | Plan integration Tasks | 1d | 2010-02-04 | 2010-02-04 |  | 16d |  |  |  |
| 214 | 1.2.21.12 | **User Profile** | 1d | 2010-02-04 | 2010-02-04 |  | 16d |  | SharePoint 2010 Architect | 8h |
| 215 | 1.2.21.12.1 | Plan integration Tasks | 1d | 2010-02-04 | 2010-02-04 |  | 16d |  |  |  |
| 216 | 1.2.21.13 | **Visio Graphics** | 1d | 2010-02-04 | 2010-02-04 |  | 16d |  | SharePoint 2010 Architect | 8h |
| 217 | 1.2.21.13.1 | Plan integration Tasks | 1d | 2010-02-04 | 2010-02-04 |  | 16d |  |  |  |
| 218 | 1.2.21.14 | **Web Analytics** | 1d | 2010-02-04 | 2010-02-04 |  | 16d |  | SharePoint 2010 Architect | 8h |
| 219 | 1.2.21.14.1 | Plan integration Tasks | 1d | 2010-02-04 | 2010-02-04 |  | 16d |  |  |  |
| 220 | 1.2.21.15 | **Word Automation** | 1d | 2010-02-04 | 2010-02-04 |  | 16d |  | SharePoint 2010 Architect | 8h |
| 221 | 1.2.21.15.1 | Plan integration Tasks | 1d | 2010-02-04 | 2010-02-04 |  | 16d |  |  |  |
| 222 | 1.2.21.16 | Plan for incoming email | 1d | 2010-02-04 | 2010-02-04 |  | 16d |  | SharePoint 2010 Architect | 8h |
| 223 | 1.2.21.17 | Identify other systems for integration | 1d | 2010-02-04 | 2010-02-04 |  | 12d | 0d | SharePoint 2010 Architect | 8h |
| 224 | 1.2.21.18 | Determine integration strategy | 1d | 2010-02-05 | 2010-02-05 | 223 | 12d | 0d | SharePoint 2010 Architect | 8h |
| 225 | 1.2.21.19 | Develop plan for integration | 1d | 2010-02-08 | 2010-02-08 | 224 | 12d | 0d | SharePoint 2010 Architect | 8h |
| 226 | 1.2.21.20 | Document as needed | 1d | 2010-02-09 | 2010-02-09 | 225 | 12d | 0d | SharePoint 2010 Architect | 8h |
| 227 | 1.2.21.21 | Plan integration complete | 1d | 2010-02-10 | 2010-02-10 | 226 | 12d |  |  |  |
| 228 | 1.2.22 | **Plan Maintenance** | 2d | 2010-02-04 | 2010-02-05 | 62 | 15d |  |  | 48h |
| 229 | 1.2.22.1 | Plan backup and restore | 1d | 2010-02-04 | 2010-02-04 |  | 15d | 0d | SharePoint 2010 Architect | 8h |
| 230 | 1.2.22.2 | Plan other routine maintenance | 1d | 2010-02-04 | 2010-02-04 |  | 15d | 0d | SharePoint 2010 Architect | 8h |
| 231 | 1.2.22.3 | Determine quotas to manage site collection storage sizes | 1d | 2010-02-04 | 2010-02-04 |  | 16d |  | SharePoint 2010 Architect | 8h |
| 232 | 1.2.22.4 | Configure zones, alternate acces mappings, etc. | 1d | 2010-02-04 | 2010-02-04 |  | 16d |  | SharePoint 2010 Architect | 8h |
| 233 | 1.2.22.5 | Determine site use confirmation and deletion to manage unused site collections / notification schedule | 1d | 2010-02-04 | 2010-02-04 |  | 16d |  | SharePoint 2010 Architect | 8h |
| 234 | 1.2.22.6 | Document as needed | 1d | 2010-02-04 | 2010-02-04 |  | 16d |  | SharePoint 2010 Architect | 8h |
| 235 | 1.2.22.7 | Plan maintenance complete | 1d | 2010-02-05 | 2010-02-05 | 229, 230 | 15d |  |  |  |

| ID | WBS | Task | Duration | Start | Finish | Predecessors | Total slack | Resources | Work |
| --- | --- | --- | --- | --- | --- | --- | --- | --- | --- |
| 236 | 1.2.23 | **Plan Content and Navigation Structure** | 1d | 2010-01-13 | 2010-01-13 |  | 64d |  | 48h |
| 237 | 1.2.23.1 | Create detailed wireframes for site and page structure | 1d | 2010-01-13 | 2010-01-13 |  | 64d | StakeHolders | 8h |
| 238 | 1.2.23.2 | Identify additional content and design requirements | 1d | 2010-01-13 | 2010-01-13 |  | 64d | StakeHolders | 8h |
| 239 | 1.2.23.3 | Identify custom development requirements | 1d | 2010-01-13 | 2010-01-13 |  | 64d | StakeHolders | 8h |
| 240 | 1.2.23.4 | Establish and maintain user experience best practice guidelines | 1d | 2010-01-13 | 2010-01-13 |  | 64d | StakeHolders | 8h |
| 241 | 1.2.23.5 | Establish content type / page layout creation review group | 1d | 2010-01-13 | 2010-01-13 |  | 64d | StakeHolders | 8h |
| 242 | 1.2.23.6 | Maintain brand consistency and design standards for templates | 1d | 2010-01-13 | 2010-01-13 |  | 64d | StakeHolders | 8h |
| 243 | 1.2.24 | Document as needed | 1d | 2010-01-13 | 2010-01-13 |  | 64d | Project Manager | 8h |
| 244 | 1.2.25 | Planning complete | 1d | 2010-03-01 | 2010-03-01 | 75, 81, 163, 183, 191, 228, 138, 90, 98, 112 | 0d | SharePoint 2010 Architect | 8h |
| 245 | 1.2.26 | Deployment approved | 1d | 2010-03-02 | 2010-03-02 | 244 | 0d | SharePoint 2010 Architect | 8h |
| 246 | 1.3 | **BUILD PHASE: Deployment, Implementation and Configuration Management** | 25d | 2010-03-03 | 2010-04-06 | 245 | 0d |  | 1352h |
| 247 | 1.3.1 | **Deploy Pilot System** | 3d | 2010-03-03 | 2010-03-05 |  | 0d |  | 144h |
| 248 | 1.3.1.1 | Install Hardware | 1d | 2010-03-03 | 2010-03-03 |  | 24d | Interfacing Teams; SharePoint Administrator | 16h |
| 249 | 1.3.1.2 | **Install Software** | 1d | 2010-03-03 | 2010-03-03 |  | 24d | Interfacing Teams; SharePoint Administrator | 48h |
| 250 | 1.3.1.2.1 | **Configure Software** | 1d | 2010-03-03 | 2010-03-03 |  | 24d | Interfacing Teams; SharePoint Administrator | 32h |
| 251 | 1.3.1.2.1.1 | Configure Search | 1d | 2010-03-03 | 2010-03-03 |  | 24d | Interfacing Teams; SharePoint Administrator | 16h |
| 252 | 1.3.1.3 | **Test and Evaluate Pilot** | 1d | 2010-03-03 | 2010-03-03 |  | 0d | Interfacing Teams; SharePoint Administrator | 48h |
| 253 | 1.3.1.3.1 | Test SharePoint 2010 | 1d | 2010-03-03 | 2010-03-03 |  | 0d | Test/QA Lead | 8h |
| 254 | 1.3.1.3.2 | Test search and index | 1d | 2010-03-03 | 2010-03-03 |  | 0d | Test/QA Lead | 8h |
| 255 | 1.3.1.3.3 | Test features and solutions | 1d | 2010-03-03 | 2010-03-03 |  | 0d | Test/QA Lead | 8h |
| 256 | 1.3.1.3.4 | Test custom integration | 1d | 2010-03-03 | 2010-03-03 |  | 0d | Test/QA Lead | 8h |
| 257 | 1.3.1.4 | Deploy pilot system complete | 1d | 2010-03-04 | 2010-03-04 | 252 | 0d | Interfacing Teams; SharePoint Administrator | 16h |
| 258 | 1.3.1.5 | Production deployment approved | 1d | 2010-03-05 | 2010-03-05 | 257 | 0d | Interfacing Teams; SharePoint Administrator | 16h |
| 259 | 1.3.2 | Deploy applicable Dev, Test, Staging environments | 1d | 2010-03-08 | 2010-03-08 | 258 | 0d | Interfacing Teams; SharePoint Administrator | 16h |
| 260 | 1.3.3 | User acceptance and business requirements signoff | 1d | 2010-03-09 | 2010-03-09 | 259 | 0d | Interfacing Teams; SharePoint Administrator | 16h |
| 261 | 1.3.4 | Production Go/No-Go Decision | 1d | 2010-03-10 | 2010-03-10 | 260 | 0d | Interfacing Teams; SharePoint Administrator | 16h |

| ID | WBS | Task | Duration | Start | Finish | Predecessors | Total slack | Free slack | Resources | Work |
| --- | --- | --- | --- | --- | --- | --- | --- | --- | --- | --- |
| 262 | 1.3.5 | **Deploy Production System** | 19d | 2010-03-11 | 2010-04-06 | 261 | 0d |  |  | 1144h |
| 263 | 1.3.5.1 | **Install Hardware** | 2d | 2010-03-11 | 2010-03-12 |  | 0d |  |  | 24h |
| 264 | 1.3.5.1.1 | Order new hardware as required | 1d | 2010-03-11 | 2010-03-11 |  | 0d |  | SharePoint 2010 Architect | 8h |
| 265 | 1.3.5.1.2 | Configure new hardware | 1d | 2010-03-12 | 2010-03-12 | 264 | 0d |  | SharePoint 2010 Architect | 8h |
| 266 | 1.3.5.1.3 | Document as needed | 1d | 2010-03-11 | 2010-03-11 |  | 18d |  | SharePoint 2010 Architect | 8h |
| 267 | 1.3.5.2 | **Install Software** | 16d | 2010-03-15 | 2010-04-05 | 265 | 0d |  |  | 776h |
| 268 | 1.3.5.2.1 | Install operating system(s) and prerequisites (.NET, etc.) | 1d | 2010-03-15 | 2010-03-15 |  | 14d | 0d | SharePoint 2010 Architect | 8h |
| 269 | 1.3.5.2.2 | Setup load balancing solution | 1d | 2010-03-16 | 2010-03-16 | 268 | 14d |  | SharePoint 2010 Architect | 8h |
| 270 | 1.3.5.2.3 | Install operating system(s) | 1d | 2010-03-15 | 2010-03-15 |  | 0d |  | SharePoint 2010 Architect | 8h |
| 271 | 1.3.5.2.4 | Install Windows SharePoint Services | 1d | 2010-03-16 | 2010-03-16 | 270 | 0d |  | SharePoint 2010 Architect | 8h |
| 272 | 1.3.5.2.5 | Setup network load balancing | 1d | 2010-03-17 | 2010-03-17 | 271 | 0d |  | SharePoint 2010 Architect | 8h |
| 273 | 1.3.5.2.6 | Install Microsoft SharePoint 2010 | 1d | 2010-03-18 | 2010-03-18 | 272 | 0d |  | SharePoint 2010 Architect | 8h |
| 274 | 1.3.5.2.7 | Install SQL Server | 1d | 2010-03-19 | 2010-03-19 | 273 | 0d |  | Database Administrator | 8h |
| 275 | 1.3.5.2.8 | Install any failover/disaster recovery software | 1d | 2010-03-22 | 2010-03-22 | 274 | 0d |  | SharePoint 2010 Architect | 8h |
| 276 | 1.3.5.2.9 | Install Microsoft Data Protection Manager (DPM) if needed | 1d | 2010-03-23 | 2010-03-23 | 275 | 0d |  | SharePoint 2010 Architect | 8h |
| 277 | 1.3.5.2.10 | Install SharePoint management pack for MOM if needed | 1d | 2010-03-24 | 2010-03-24 | 276 | 0d |  | SharePoint 2010 Architect | 8h |
| 278 | 1.3.5.2.11 | Configure Web front end server(s) | 1d | 2010-03-25 | 2010-03-25 | 277 | 0d |  | SharePoint 2010 Architect | 8h |
| 279 | 1.3.5.2.12 | Configure index and query services | 1d | 2010-03-26 | 2010-03-26 | 278 | 0d |  | SharePoint 2010 Architect | 8h |
| 280 | 1.3.5.2.13 | Configure search server (if large farm deployment) | 1d | 2010-03-29 | 2010-03-29 | 279 | 0d |  | SharePoint 2010 Architect | 8h |
| 281 | 1.3.5.2.14 | Configure application servers (if topology requires) | 1d | 2010-03-30 | 2010-03-30 | 280 | 4d |  | SharePoint 2010 Architect | 8h |
| 282 | 1.3.5.2.15 | Add and Configure crawl components (if topology requires) | 1d | 2010-03-15 | 2010-03-15 |  | 15d |  | SharePoint 2010 Architect | 8h |
| 283 | 1.3.5.2.16 | Install and register filters / ifilters | 1d | 2010-03-15 | 2010-03-15 |  | 15d |  | SharePoint 2010 Architect | 8h |
| 284 | 1.3.5.2.17 | Document as needed | 1d | 2010-03-15 | 2010-03-15 |  | 15d |  | SharePoint 2010 Architect | 8h |
| 285 | 1.3.5.2.18 | **Configure Software** | 5d | 2010-03-30 | 2010-04-05 | 280 | 0d |  |  | 640h |
| 286 | 1.3.5.2.18.1 | Configure site templates | 1d | 2010-03-30 | 2010-03-30 |  | 2d | 0d | SharePoint 2010 Administrator; SharePoint 2010 Architect | 16h |
| 287 | 1.3.5.2.18.2 | Apply branding and design elements | 1d | 2010-03-31 | 2010-03-31 | 286 | 2d | 0d | SharePoint 2010 Administrator; SharePoint 2010 Architect | 16h |
| 288 | 1.3.5.2.18.3 | Configure e-mail settings | 1d | 2010-04-01 | 2010-04-01 | 287 | 2d |  | SharePoint 2010 Administrator; SharePoint 2010 Architect | 16h |
| 289 | 1.3.5.2.18.4 | Configure usage analysis | 1d | 2010-03-30 | 2010-03-30 |  | 4d |  | SharePoint 2010 Architect; SharePoint 2010 Administrator | 16h |
| 290 | 1.3.5.2.18.5 | Configure antivirus protection | 1d | 2010-03-30 | 2010-03-30 |  | 4d |  | SharePoint 2010 Architect; SharePoint 2010 Administrator | 16h |
| 291 | 1.3.5.2.18.6 | Configure blocked files | 1d | 2010-03-30 | 2010-03-30 |  | 4d |  | SharePoint 2010 Administrator; SharePoint 2010 Architect | 16h |
| 292 | 1.3.5.2.18.7 | Configure security | 1d | 2010-03-30 | 2010-03-30 |  | 4d |  | SharePoint 2010 Administrator; SharePoint 2010 Architect | 16h |
| 293 | 1.3.5.2.18.8 | Configure user profiles | 1d | 2010-03-30 | 2010-03-30 |  | 4d |  | SharePoint 2010 Administrator; SharePoint 2010 Architect | 16h |
| 294 | 1.3.5.2.18.9 | Configure audiences | 1d | 2010-03-30 | 2010-03-30 |  | 4d |  | SharePoint 2010 Administrator; SharePoint 2010 Architect | 16h |
| 295 | 1.3.5.2.18.10 | Configure SSL | 1d | 2010-03-30 | 2010-03-30 |  | 4d |  | SharePoint 2010 Administrator; SharePoint 2010 Architect | 16h |
| 296 | 1.3.5.2.18.11 | Configure ISA/Firewalls | 1d | 2010-03-30 | 2010-03-30 |  | 4d |  | SharePoint 2010 Administrator; SharePoint 2010 Architect; Interfacing Teams | 24h |
| 297 | 1.3.5.2.18.12 | Set web application quota templates and choose site collection quotas | 1d | 2010-03-30 | 2010-03-30 |  | 4d |  | SharePoint 2010 Administrator; SharePoint 2010 Architect | 16h |
| 298 | 1.3.5.2.18.13 | Configure CAS/Security Levels | 1d | 2010-03-30 | 2010-03-30 |  | 4d |  | SharePoint 2010 Administrator; SharePoint 2010 Architect | 16h |
| 299 | 1.3.5.2.18.14 | Determine self service site provisioning | 1d | 2010-03-30 | 2010-03-30 |  | 4d |  | SharePoint 2010 Administrator; SharePoint 2010 Architect | 16h |
| 300 | 1.3.5.2.18.15 | Configure permissions and information policies | 1d | 2010-03-30 | 2010-03-30 |  | 4d |  | SharePoint 2010 Administrator; SharePoint 2010 Architect | 16h |
| 301 | 1.3.5.2.18.16 | Configure SharePoint Health Analysis and Reporting Features | 1d | 2010-03-30 | 2010-03-30 |  | 4d |  | SharePoint 2010 Administrator; SharePoint 2010 Architect | 16h |
| 302 | 1.3.5.2.18.17 | Configure interfacing / third party software to be joined | 1d | 2010-03-30 | 2010-03-30 |  | 4d |  | SharePoint 2010 Administrator; SharePoint 2010 Architect | 16h |
| 303 | 1.3.5.2.18.18 | Configure Recycle Bin retention and Site Delete Confirmation | 1d | 2010-03-30 | 2010-03-30 |  | 4d |  | SharePoint 2010 Administrator; SharePoint 2010 Architect | 16h |
| 304 | 1.3.5.2.18.19 | Deploy custom solutions and features | 1d | 2010-03-30 | 2010-03-30 |  | 4d |  | SharePoint 2010 Administrator; SharePoint 2010 Architect | 16h |
| 305 | 1.3.5.2.18.20 | Document as needed | 1d | 2010-03-30 | 2010-03-30 |  | 4d |  | SharePoint 2010 Administrator; SharePoint 2010 Architect | 16h |

| ID | WBS | Task | Duration | Start | Finish | Predecessors | Total slack | Resources | Work |
| --- | --- | --- | --- | --- | --- | --- | --- | --- | --- |
| 306 | 1.3.5.2.18.21 | **Configure Search** | 1d | 2010-03-30 | 2010-03-30 |  | 4d |  | 128h |
| 307 | 1.3.5.2.18.21.1 | Install and register filters | 1d | 2010-03-30 | 2010-03-30 |  | 4d | SharePoint 2010 Administrator; SharePoint 2010 Architect | 16h |
| 308 | 1.3.5.2.18.21.2 | Configure content locations | 1d | 2010-03-30 | 2010-03-30 |  | 4d | SharePoint 2010 Administrator; SharePoint 2010 Architect | 16h |
| 309 | 1.3.5.2.18.21.3 | Modify noise word and thesaurus files and create custom search queries | 1d | 2010-03-30 | 2010-03-30 |  | 4d | SharePoint 2010 Administrator; SharePoint 2010 Architect | 16h |
| 310 | 1.3.5.2.18.21.4 | Maintenance for indexing | 1d | 2010-03-30 | 2010-03-30 |  | 4d | SharePoint 2010 Administrator; SharePoint 2010 Architect | 16h |
| 311 | 1.3.5.2.18.21.5 | Configure best bets and keywords for search | 1d | 2010-03-30 | 2010-03-30 |  | 4d | SharePoint 2010 Administrator; SharePoint 2010 Architect | 16h |
| 312 | 1.3.5.2.18.21.6 | Configure search scopes | 1d | 2010-03-30 | 2010-03-30 |  | 4d | SharePoint 2010 Administrator; SharePoint 2010 Architect | 16h |
| 313 | 1.3.5.2.18.21.7 | Establish and implement search monitoring and tuning plan | 1d | 2010-03-30 | 2010-03-30 |  | 4d | SharePoint 2010 Administrator; SharePoint 2010 Architect | 16h |
| 314 | 1.3.5.2.18.21.8 | Document as needed | 1d | 2010-03-30 | 2010-03-30 |  | 4d | SharePoint 2010 Administrator; SharePoint 2010 Architect | 16h |
| 315 | 1.3.5.2.18.22 | **Configure Document Management** | 5d | 2010-03-30 | 2010-04-05 |  | 0d | SharePoint 2010 Administrator; SharePoint 2010 Architect | 152h |
| 316 | 1.3.5.2.18.22.1 | **Create Folder Structure** | 2d | 2010-03-30 | 2010-03-31 |  | 0d |  | 32h |
| 317 | 1.3.5.2.18.22.1.1 | Assign roles for security | 1d | 2010-03-30 | 2010-03-30 |  | 0d | SharePoint 2010 Administrator; SharePoint 2010 Architect | 16h |
| 318 | 1.3.5.2.18.22.1.2 | Choose publishing process | 1d | 2010-03-31 | 2010-03-31 | 317 | 3d | SharePoint 2010 Administrator | 8h |
| 319 | 1.3.5.2.18.22.1.3 | Add approval routing | 1d | 2010-03-31 | 2010-03-31 | 317 | 0d | SharePoint 2010 Administrator | 8h |
| 320 | 1.3.5.2.18.22.2 | **Create Document Profiles and Custom Profiles** | 2d | 2010-04-01 | 2010-04-02 |  | 0d |  | 24h |
| 321 | 1.3.5.2.18.22.2.1 | Plan document profiles | 1d | 2010-04-01 | 2010-04-01 | 319 | 2d | SharePoint 2010 Administrator | 8h |
| 322 | 1.3.5.2.18.22.2.2 | Emphasize subjects with keywords | 1d | 2010-04-01 | 2010-04-01 | 319 | 0d | SharePoint 2010 Administrator | 8h |
| 323 | 1.3.5.2.18.22.2.3 | Enable Web discussions | 1d | 2010-04-02 | 2010-04-02 | 322 | 0d | SharePoint 2010 Administrator | 8h |
| 324 | 1.3.5.2.18.22.3 | **Move Documents into the Workspace** | 1d | 2010-04-05 | 2010-04-05 |  | 0d |  | 16h |
| 325 | 1.3.5.2.18.22.3.1 | Move multiple individual documents | 1d | 2010-04-05 | 2010-04-05 | 323 | 0d | SharePoint 2010 Administrator | 8h |
| 326 | 1.3.5.2.18.22.3.2 | Import existing folders | 1d | 2010-04-05 | 2010-04-05 | 323 | 0d | SharePoint 2010 Administrator | 8h |
| 327 | 1.3.5.2.18.23 | Configure alerts | 1d | 2010-03-30 | 2010-03-30 |  | 4d | SharePoint 2010 Administrator | 8h |
| 328 | 1.3.5.2.18.24 | Configure personal sites | 1d | 2010-03-30 | 2010-03-30 |  | 4d | SharePoint 2010 Administrator | 8h |
| 329 | 1.3.5.2.18.25 | Review single sign-on service requirements, consider Kerberos | 1d | 2010-03-30 | 2010-03-30 |  | 4d | SharePoint 2010 Administrator | 8h |
| 330 | 1.3.5.2.18.26 | Configure Microsoft SharePoint 2010 for extranet use as desired | 1d | 2010-03-30 | 2010-03-30 |  | 4d | SharePoint 2010 Administrator | 8h |
| 331 | 1.3.5.3 | Implement solutions and applicable third party solutions if any | 1d | 2010-04-06 | 2010-04-06 | 267 | 0d | SharePoint 2010 Architect; SharePoint 2010 Administrator | 16h |
| 332 | 1.3.5.4 | Implement interop and BDC integration | 1d | 2010-04-06 | 2010-04-06 | 267 | 0d | SharePoint 2010 Architect; SharePoint 2010 Administrator | 16h |
| 333 | 1.3.5.5 | Document as needed | 1d | 2010-03-11 | 2010-03-11 |  | 18d | SharePoint 2010 Architect; SharePoint 2010 Administrator | 16h |

| ID | WBS | Task | Duration | Start | Finish | Total slack | Free slack | Resources | Work |
| --- | --- | --- | --- | --- | --- | --- | --- | --- | --- |
| 334 | 1.3.5.6 | **Deploy updates to Client Machines as needed** | 1d | 2010-03-11 | 2010-03-11 | 18d |  |  | 64h |
| 335 | 1.3.5.6.1 | Update client operating systems as needed | 1d | 2010-03-11 | 2010-03-11 | 18d |  | Desktop Administrator; Interfacing Teams | 16h |
| 336 | 1.3.5.6.2 | Update client browsers as needed | 1d | 2010-03-11 | 2010-03-11 | 18d |  | Desktop Administrator; Interfacing Teams | 16h |
| 337 | 1.3.5.6.3 | Update client software as needed | 1d | 2010-03-11 | 2010-03-11 | 18d |  | Desktop Administrator; Interfacing Teams | 16h |
| 338 | 1.3.5.6.4 | Document as needed | 1d | 2010-03-11 | 2010-03-11 | 18d |  | Desktop Administrator; Interfacing Teams | 16h |
| 339 | 1.3.5.7 | **Test and Evaluate System** | 1d | 2010-03-11 | 2010-03-11 | 16d | 0d |  | 216h |
| 340 | 1.3.5.7.1 | **Test SharePoint 2010** | 1d | 2010-03-11 | 2010-03-11 | 16d |  |  | 216h |
| 341 | 1.3.5.7.1.1 | Test based on usage patterns and business scenarios | 1d | 2010-03-11 | 2010-03-11 | 16d |  | Test/QA Lead | 8h |
| 342 | 1.3.5.7.1.2 | Test search and indexing | 1d | 2010-03-11 | 2010-03-11 | 16d |  | Test/QA Lead | 8h |
| 343 | 1.3.5.7.1.3 | Test solutions | 1d | 2010-03-11 | 2010-03-11 | 16d |  | Test/QA Lead | 8h |
| 344 | 1.3.5.7.1.4 | Test integrations | 1d | 2010-03-11 | 2010-03-11 | 16d |  | Test/QA Lead | 8h |
| 345 | 1.3.5.7.1.5 | Test Security and Hardening - evaluate for intrusion detection as needed | 1d | 2010-03-11 | 2010-03-11 | 16d |  | Test/QA Lead | 8h |
| 346 | 1.3.5.7.1.6 | Document as needed | 1d | 2010-03-11 | 2010-03-11 | 16d |  | Test/QA Lead | 8h |
| 347 | 1.3.5.7.1.7 | **Training** | 1d | 2010-03-11 | 2010-03-11 | 16d |  |  | 168h |
| 348 | 1.3.5.7.1.7.1 | **System Administrator Training** | 1d | 2010-03-11 | 2010-03-11 | 16d |  |  | 32h |
| 349 | 1.3.5.7.1.7.1.1 | Identify Attendees | 1d | 2010-03-11 | 2010-03-11 | 16d |  | Education/Training Lead | 8h |
| 350 | 1.3.5.7.1.7.1.2 | Schedule System Admin Training | 1d | 2010-03-11 | 2010-03-11 | 16d |  | Education/Training Lead | 8h |
| 351 | 1.3.5.7.1.7.1.3 | Build System Admin Training | 1d | 2010-03-11 | 2010-03-11 | 16d |  | Education/Training Lead | 8h |
| 352 | 1.3.5.7.1.7.1.4 | Conduct System Administration Training | 1d | 2010-03-11 | 2010-03-11 | 16d |  | Education/Training Lead | 8h |
| 353 | 1.3.5.7.1.7.2 | Accept System Administration Training Materials | 1d | 2010-03-11 | 2010-03-11 | 16d |  | Education/Training Lead | 8h |
| 354 | 1.3.5.7.1.7.3 | **Developer Training** | 1d | 2010-03-11 | 2010-03-11 | 16d |  |  | 32h |
| 355 | 1.3.5.7.1.7.3.1 | Identify Attendees | 1d | 2010-03-11 | 2010-03-11 | 16d |  | Education/Training Lead | 8h |
| 356 | 1.3.5.7.1.7.3.2 | Schedule Developer Training | 1d | 2010-03-11 | 2010-03-11 | 16d |  | Education/Training Lead | 8h |
| 357 | 1.3.5.7.1.7.3.3 | Build Developer Training | 1d | 2010-03-11 | 2010-03-11 | 16d |  | Education/Training Lead | 8h |
| 358 | 1.3.5.7.1.7.3.4 | Conduct Developer Training | 1d | 2010-03-11 | 2010-03-11 | 16d |  | Education/Training Lead | 8h |
| 359 | 1.3.5.7.1.7.4 | Accept Developer Training Materials | 1d | 2010-03-11 | 2010-03-11 | 16d |  | Education/Training Lead | 8h |

| ID | WBS | Task | Duration | Start | Finish | Predecessors | Total slack | Free slack | Resources | Work |
| --- | --- | --- | --- | --- | --- | --- | --- | --- | --- | --- |
| 360 | 1.3.5.7.1.7.5 | **Train StakeHolders** | 1d | 2010-03-11 | 2010-03-11 |  | 16d |  |  | 32h |
| 361 | 1.3.5.7.1.7.5.1 | Identify Attendees | 1d | 2010-03-11 | 2010-03-11 |  | 16d |  | Education/Training Lead | 8h |
| 362 | 1.3.5.7.1.7.5.2 | Schedule End User Training | 1d | 2010-03-11 | 2010-03-11 |  | 16d |  | Education/Training Lead | 8h |
| 363 | 1.3.5.7.1.7.5.3 | Build End User Training | 1d | 2010-03-11 | 2010-03-11 |  | 16d |  | Education/Training Lead | 8h |
| 364 | 1.3.5.7.1.7.5.4 | Conduct End User Training | 1d | 2010-03-11 | 2010-03-11 |  | 16d |  | Education/Training Lead | 8h |
| 365 | 1.3.5.7.1.7.6 | Accept End User Training Materials | 1d | 2010-03-11 | 2010-03-11 |  | 16d |  | Education/Training Lead | 8h |
| 366 | 1.3.5.7.1.7.7 | **Support Training** | 1d | 2010-03-11 | 2010-03-11 |  | 16d |  |  | 32h |
| 367 | 1.3.5.7.1.7.7.1 | Identify Attendees | 1d | 2010-03-11 | 2010-03-11 |  | 16d |  | Education/Training Lead | 8h |
| 368 | 1.3.5.7.1.7.7.2 | Schedule Support Training | 1d | 2010-03-11 | 2010-03-11 |  | 16d |  | Education/Training Lead | 8h |
| 369 | 1.3.5.7.1.7.7.3 | Build Support Training | 1d | 2010-03-11 | 2010-03-11 |  | 16d |  | Education/Training Lead | 8h |
| 370 | 1.3.5.7.1.7.7.4 | Conduct Support Training | 1d | 2010-03-11 | 2010-03-11 |  | 16d |  | Education/Training Lead | 8h |
| 371 | 1.3.5.7.1.7.8 | Accept Support Training Materials | 1d | 2010-03-11 | 2010-03-11 |  | 16d |  | Education/Training Lead | 8h |
| 372 | 1.3.5.7.1.7.9 | Generate plan for updating and supporting continued training | 1d | 2010-03-11 | 2010-03-11 |  | 16d |  | Education/Training Lead | 8h |
| 373 | 1.3.5.8 | Production deployment complete | 1d | 2010-03-12 | 2010-03-12 | 339 | 16d | 0d | SharePoint 2010 Architect; Database Administrator | 16h |
| 374 | 1.3.6 | Deploy production system complete | 1d | 2010-03-15 | 2010-03-15 | 373 | 16d |  | SharePoint 2010 Architect; Database Administrator | 16h |
| 375 | 1.4 | **OPERATE PHASE: Post-Implementation Operations, Optimization and Business Review** | 5d | 2010-04-07 | 2010-04-13 | 246 | 0d |  |  | 248h |
| 376 | 1.4.1 | **Maintain System** | 2d | 2010-04-07 | 2010-04-08 |  | 0d |  |  | 192h |
| 377 | 1.4.1.1 | **Backup and Restore/Disaster Recovery & Business Continuance** | 2d | 2010-04-07 | 2010-04-08 |  | 0d |  | SharePoint 2010 Administrator | 56h |
| 378 | 1.4.1.1.1 | Perform backups | 1d | 2010-04-07 | 2010-04-07 |  | 0d |  | SharePoint 2010 Administrator | 8h |
| 379 | 1.4.1.1.2 | Test restore/disaster recovery | 1d | 2010-04-08 | 2010-04-08 | 378 | 0d |  | SharePoint 2010 Architect; Database Administrator | 16h |
| 380 | 1.4.1.1.3 | Document as needed | 1d | 2010-04-07 | 2010-04-07 |  | 1d |  | SharePoint 2010 Architect; Database Administrator | 16h |
| 381 | 1.4.1.2 | **Reporting and Monitor Growth and Performance** | 1d | 2010-04-07 | 2010-04-07 |  | 1d |  |  | 120h |
| 382 | 1.4.1.2.1 | Monitor SQL Server performance | 1d | 2010-04-07 | 2010-04-07 |  | 1d |  | SharePoint 2010 Architect; Database Administrator; SharePoint 2010 Administrator | 24h |
| 383 | 1.4.1.2.2 | Monitor Web front end performance | 1d | 2010-04-07 | 2010-04-07 |  | 1d |  | SharePoint 2010 Architect; Database Administrator; SharePoint 2010 Administrator | 24h |
| 384 | 1.4.1.2.3 | Monitor search performance | 1d | 2010-04-07 | 2010-04-07 |  | 1d |  | SharePoint 2010 Architect; Database Administrator; SharePoint 2010 Administrator | 24h |
| 385 | 1.4.1.2.4 | Re-forecast system requirements and capacity | 1d | 2010-04-07 | 2010-04-07 |  | 1d |  | SharePoint 2010 Architect; Database Administrator | 16h |
| 386 | 1.4.1.2.5 | Plan for additional capacity as needed | 1d | 2010-04-07 | 2010-04-07 |  | 1d |  | SharePoint 2010 Architect; Database Administrator | 16h |
| 387 | 1.4.1.2.6 | Weekly performance review (storage, performance, growth, trends, etc.) | 1d | 2010-04-07 | 2010-04-07 |  | 1d |  | SharePoint 2010 Administrator; SharePoint 2010 Architect | 16h |
| 388 | 1.4.1.3 | Resolve client/connectivity issues | 1d | 2010-04-07 | 2010-04-07 |  | 1d |  | SharePoint 2010 Architect; Desktop Administrator | 16h |
| 389 | 1.4.2 | Maintain web parts library | 1d | 2010-04-07 | 2010-04-07 |  | 4d |  | SharePoint 2010 Architect; Desktop Administrator | 16h |
| 390 | 1.4.3 | Continuous documentation of user feedback | 1d | 2010-04-09 | 2010-04-09 | 376 | 0d |  | Project Manager; StakeHolders | 16h |
| 391 | 1.4.4 | UI and structure updates as necessary | 1d | 2010-04-12 | 2010-04-12 | 390 | 0d |  | Project Manager; StakeHolders | 16h |
| 392 | 1.4.5 | Post-implementation review complete | 1d | 2010-04-13 | 2010-04-13 | 391 | 0d |  | SharePoint 2010 Architect | 8h |
| 393 | 1.5 | Deployment complete | 1d | 2010-01-01 | 2010-01-01 |  | 72d |  | SharePoint 2010 Architect | 8h |
| 394 | 1.6 | Weekly operations meeting | 1d | 2010-01-01 | 2010-01-01 |  | 72d |  | Project Manager | 8h |
| 395 | 1.7 | Monthly business review | 1d | 2010-01-01 | 2010-01-01 |  | 72d |  | Project Manager | 8h |
| 396 | 1.8 | Monthly technical / infrastructure review | 1d | 2010-01-01 | 2010-01-01 |  | 72d |  | Project Manager | 8h |
| 397 | 1.9 | Continue recuring business and technical reviews as necessary | 1d | 2010-01-01 | 2010-01-01 |  | 72d |  | Project Manager | 8h |
| 398 | 1.10 | Review environment for migrations, departmental solutions, service packs and hotfixes updates as needed | 1d | 2010-01-01 | 2010-01-01 |  | 72d |  | Project Manager | 8h |
